# ЛП

Schedule from MS Project, 2023-01-02 to 2023-12-01, costs in ₽.

## Calendars

- Стандартный: Mon-Fri 09:00-13:00, 14:00-18:00; Sat-Sun off.

## Resources

| Resource | Rate |
| --- | --- |
| Программист | 700 |
| 3D-моделлер 1 | 500 |
| Game-дизайнер, руководитель | 700 |
| Unity-разработчик | 700 |
| Разработчик баз данных | 700 |
| 3D-моделлер 2 | 500 |

## Schedule

| ID | Task | Duration | Start | Finish | Predecessors | Total slack | Free slack | Constraint | Resources | Work | Cost |
| --- | --- | --- | --- | --- | --- | --- | --- | --- | --- | --- | --- |
| 1 | Анализ нормативной документации (определение зависимостей, связей, параметров) | 30d | 2023-01-02 | 2023-02-10 |  | 0d |  | start no earlier than 2023-01-02 | Game-дизайнер, руководитель | 240h | 168,000 |
| 2 | Формировани ТЗ (согласование функционала и содержания проекта) | 30d | 2023-02-13 | 2023-03-24 | 1 | 0d |  |  | Game-дизайнер, руководитель | 240h | 168,000 |
| 3 | Моделирование подвижного состава | 90d | 2023-03-27 | 2023-07-28 | 2 | 0d |  | start no earlier than 2023-01-02 | 3D-моделлер 1 | 720h | 360,000 |
| 4 | Моделирование окружения и инфраструктуры | 90d | 2023-03-27 | 2023-07-28 | 2 | 90d |  |  | 3D-моделлер 2 | 720h | 360,000 |
| 5 | Настройка физики | 30d | 2023-03-27 | 2023-05-05 | 2 | 90d | 0d |  | Unity-разработчик | 240h | 168,000 |
| 6 | Сборка интерфейса приложения | 30d | 2023-05-08 | 2023-06-16 | 5 | 90d | 0d |  | Unity-разработчик | 240h | 168,000 |
| 7 | Сборка библиотеки | 30d | 2023-06-19 | 2023-07-28 | 6 | 90d |  |  | Unity-разработчик | 240h | 168,000 |
| 8 | Программирование параметров ликвидации | 30d | 2023-03-27 | 2023-05-05 | 2 | 90d | 0d |  | Программист; Game-дизайнер, руководитель | 480h | 336,000 |
| 9 | Программирование диаграммы ганта | 30d | 2023-05-08 | 2023-06-16 | 8 | 90d | 0d |  | Программист; Game-дизайнер, руководитель | 480h | 336,000 |
| 10 | Программирование библиотеки | 30d | 2023-06-19 | 2023-07-28 | 9 | 90d |  |  | Программист; Game-дизайнер, руководитель | 480h | 336,000 |
| 11 | Опробация (демо-тестирование) | 30d | 2023-07-31 | 2023-09-08 | 3 | 0d |  |  |  |  |  |
| 12 | Анализ результатов и корректировка проекта | 30d | 2023-09-11 | 2023-10-20 | 11 | 0d |  |  | 3D-моделлер 1; Программист; Game-дизайнер, руководитель; Unity-разработчик | 960h | 624,000 |
| 13 | Документаци, оформление, внедрение | 30d | 2023-10-23 | 2023-12-01 | 12 | 0d |  |  | Game-дизайнер, руководитель | 240h | 168,000 |
